# HRA Project Plan

Schedule from MS Project, 2011-10-31 to 2012-12-05, A marks actual dates.
Microsoft

## Calendars

- Standard: Mon-Fri 08:00-12:00, 13:00-17:00; Sat-Sun off. Exceptions (off unless hours are given): 2011-11-24 (Thanksgiving Day), 2011-11-25 (Thanksgiving Friday), 2011-12-23 (Special MIT Holiday 1), 2011-12-26 (Christmas Day Observed), 2011-12-30 (Special MIT Holiday 2), 2012-01-02 (New Years Day Observed), 2012-01-16 (Martin Luther King Birthday), 2012-02-20 (Presidents Day).

## Resources

| Resource |
| --- |
| Ross |
| Jonathan |
| Robin |
| Janet |

## Schedule

| ID | WBS | Task | Type | Duration | Start | Finish | Predecessors | Complete | Remaining | Total slack | Constraint | Resources | Work | Actual work |
| --- | --- | --- | --- | --- | --- | --- | --- | --- | --- | --- | --- | --- | --- | --- |
| 1 | 1 | **Housing Replacement Analysis Project** |  | 280d | 2011-10-31 A | 2012-12-05 |  | 31% | 193.49d | 0d |  |  | 1695.04h | 981.92h |
| 2 | 1.1 | Project Kickoff Meeting |  | 1d | 2011-10-31 | 2011-10-31 |  |  |  | 305.5d |  |  |  |  |
| 3 | 1.2 | **Discovery Phase (as-is)** |  | 176d | 2011-11-04 A | 2012-07-18 |  | 40% | 106.24d | 0d |  |  | 1695.04h | 981.92h |
| 4 | 1.2.1 | **Business Justification** |  | 20d | 2011-11-04 A | 2011-12-06 A | 2 | 100% |  |  |  |  | 136h | 136h |
| 5 | 1.2.1.1 | Write Business Justification |  | 10d | 2011-11-14 A | 2011-11-25 A | 6 | 100% |  |  | start no earlier than 2011-11-01 | Jonathan | 80h | 80h |
| 6 | 1.2.1.2 | Review Business Justification |  | 6d | 2011-11-04 A | 2011-11-11 A |  | 100% |  |  | finish no earlier than 2011-11-11 | Jonathan | 48h | 48h |
| 7 | 1.2.1.3 | Obtain Approval from Project Team |  | 1d | 2011-11-29 A | 2011-11-29 A | 5, 6 | 100% |  |  | start no earlier than 2011-11-29 | Jonathan | 8h | 8h |
| 8 | 1.2.1.4 | Obtain Approval from Project Sponsors | milestone | 0d | 2011-12-06 A | 2011-12-06 A | 7 | 100% |  |  | start no earlier than 2011-12-06 | Jonathan |  |  |
| 9 | 1.2.1.5 | Business Justification completed | milestone | 0d | 2011-12-06 A | 2011-12-06 A | 8 | 100% |  |  |  | Jonathan |  |  |
| 10 | 1.2.2 | **Project Scope Document** |  | 19d | 2011-11-07 A | 2011-12-06 A | 2 | 100% |  |  |  |  | 56h | 56h |
| 11 | 1.2.2.1 | Write Project Scope Document |  | 5d | 2011-11-07 A | 2011-11-11 A |  | 100% |  |  | finish no earlier than 2011-11-11 | Jonathan | 40h | 40h |
| 12 | 1.2.2.2 | Review Project Scope Document |  | 1d | 2011-11-18 A | 2011-11-18 A | 11 | 100% |  |  | finish no earlier than 2011-11-18 | Jonathan | 8h | 8h |
| 13 | 1.2.2.3 | Obtain Approval from Project Team |  | 1d | 2011-11-29 A | 2011-11-29 A |  | 100% |  |  | start no earlier than 2011-11-29 | Jonathan | 8h | 8h |
| 14 | 1.2.2.4 | Obtain Approval from Project Sponsors | milestone | 0d | 2011-12-06 A | 2011-12-06 A |  | 100% |  |  | start no earlier than 2011-12-06 | Jonathan |  |  |
| 15 | 1.2.2.5 | Project Scope completed | milestone | 0d | 2011-12-06 A | 2011-12-06 A |  | 100% |  |  | start no earlier than 2011-12-06 | Jonathan |  |  |
| 16 | 1.2.3 | **Discovery Meetings** |  | 109d | 2011-12-15 A | 2012-05-23 | 4, 10 | 70% | 32.76d | 0d |  |  | 991.04h | 789.92h |
| 17 | 1.2.3.1 | System Diagram (IS&T) |  | 7d | 2011-12-15 A | 2012-02-03 |  | 50% | 3.5d | 77d |  | Ross [44%] | 24.64h | 12.32h |
| 18 | 1.2.3.2 | **Housing / Lottery** |  | 77d | 2011-12-15 A | 2012-04-09 |  | 17% | 64.17d | 32d |  |  | 81.6h | 6.4h |
| 19 | 1.2.3.2.1 | Freshman (new to the Institute) |  | 2d | 2011-12-15 A | 2011-12-16 A |  | 100% |  |  | start no earlier than 2011-12-15 | Ross [40%] | 6.4h | 6.4h |
| 20 | 1.2.3.2.2 | Upperclassman |  | 1d | 2012-04-09 | 2012-04-09 |  |  |  | 32d | start no earlier than 2012-04-09 | Ross [40%] | 3.2h |  |
| 21 | 1.2.3.2.3 | FSILG |  | 1d | 2012-04-09 | 2012-04-09 |  |  |  | 32d | start no earlier than 2012-04-09 | Ross | 8h |  |
| 22 | 1.2.3.2.4 | Off Campus Students |  | 1d | 2012-04-09 | 2012-04-09 |  |  |  | 32d | start no earlier than 2012-04-09 | Ross | 8h |  |
| 23 | 1.2.3.2.5 | Graduate Students |  | 1d | 2012-04-09 | 2012-04-09 |  |  |  | 32d | start no earlier than 2012-04-09 | Ross | 8h |  |
| 24 | 1.2.3.2.6 | Summer Students |  | 1d | 2012-04-09 | 2012-04-09 |  |  |  | 32d | start no earlier than 2012-04-09 | Ross | 8h |  |
| 25 | 1.2.3.2.7 | Post-Doctoral / Faculty |  | 1d | 2012-04-09 | 2012-04-09 |  |  |  | 32d | start no earlier than 2012-04-09 | Ross | 8h |  |
| 26 | 1.2.3.2.8 | Young Students (Legal Minors) |  | 1d | 2012-04-09 | 2012-04-09 |  |  |  | 32d | start no earlier than 2012-04-09 | Ross | 8h |  |
| 27 | 1.2.3.2.9 | Outside, Non Affiliated Groups |  | 1d | 2012-04-09 | 2012-04-09 |  |  |  | 32d | start no earlier than 2012-04-09 | Ross | 8h |  |
| 28 | 1.2.3.2.10 | MIT - Affiliated Groups |  | 1d | 2012-04-09 | 2012-04-09 |  |  |  | 32d | start no earlier than 2012-04-09 | Ross | 8h |  |
| 29 | 1.2.3.2.11 | Visitors |  | 1d | 2012-04-09 | 2012-04-09 |  |  |  | 32d | start no earlier than 2012-04-09 | Ross | 8h |  |

| ID | WBS | Task | Duration | Start | Finish | Predecessors | Complete | Total slack | Constraint | Resources | Work | Actual work |
| --- | --- | --- | --- | --- | --- | --- | --- | --- | --- | --- | --- | --- |
| 30 | 1.2.3.3 | **Housing filemaker Databases** | 10d | 2012-02-06 A | 2012-02-17 A |  | 100% |  |  |  | 232h | 232h |
| 31 | 1.2.3.3.1 | Master Blaster | 5d | 2012-02-06 A | 2012-02-10 A |  | 100% |  | start no earlier than 2012-02-06 | Janet | 40h | 40h |
| 32 | 1.2.3.3.2 | UG Confirmation | 5d | 2012-02-06 A | 2012-02-10 A |  | 100% |  | start no earlier than 2012-02-06 | Ross [40%] | 16h | 16h |
| 33 | 1.2.3.3.3 | Conference / Guest | 5d | 2012-02-06 A | 2012-02-10 A |  | 100% |  | start no earlier than 2012-02-06 | Ross [40%] | 16h | 16h |
| 34 | 1.2.3.3.4 | Vacancy | 5d | 2012-02-13 A | 2012-02-17 A |  | 100% |  | start no earlier than 2012-02-13 | Janet | 40h | 40h |
| 35 | 1.2.3.3.5 | Early Return | 5d | 2012-02-13 A | 2012-02-17 A |  | 100% |  | start no earlier than 2012-02-13 | Ross | 40h | 40h |
| 36 | 1.2.3.3.6 | Waiting List | 5d | 2012-02-13 A | 2012-02-17 A |  | 100% |  | start no earlier than 2012-02-13 | Janet | 40h | 40h |
| 37 | 1.2.3.3.7 | Front Desk | 5d | 2012-02-13 A | 2012-02-17 A |  | 100% |  | start no earlier than 2012-02-13 | Ross | 40h | 40h |
| 38 | 1.2.3.4 | Housing SISTIM Functionality on Housing | 8d | 2012-02-21 A | 2012-03-01 A |  | 100% |  | start no earlier than 2012-02-21 | Ross | 64h | 64h |
| 39 | 1.2.3.5 | Housing MITSIS Functionality on Housing | 8d | 2012-02-21 A | 2012-03-01 A |  | 100% |  | start no earlier than 2012-02-21 | Janet | 64h | 64h |
| 40 | 1.2.3.6 | **Housing Stakeholder - HFS Accounting (David Bull's Group)** | 5d | 2012-03-05 A | 2012-03-09 A | 39FS+1d | 100% |  |  |  | 240h | 240h |
| 41 | 1.2.3.6.1 | Discuss systems/applications/process flow | 5d | 2012-03-05 A | 2012-03-09 A |  | 100% |  |  | Janet | 40h | 40h |
| 42 | 1.2.3.6.2 | Discuss process calendar | 5d | 2012-03-05 A | 2012-03-09 A |  | 100% |  |  | Janet | 40h | 40h |
| 43 | 1.2.3.6.3 | Walkthrough of digital Building/Room Setup & Maintenance | 5d | 2012-03-05 A | 2012-03-09 A |  | 100% |  |  | Janet | 40h | 40h |
| 44 | 1.2.3.6.4 | Walkthrough of Room Rate Codes Setup & Maintenance | 5d | 2012-03-05 A | 2012-03-09 A |  | 100% |  |  | Janet | 40h | 40h |
| 45 | 1.2.3.6.5 | Analysis/review of OTF process | 5d | 2012-03-05 A | 2012-03-09 A |  | 100% |  |  | Janet | 40h | 40h |
| 46 | 1.2.3.6.6 | Discuss functionality/efficiency/information gaps in current assessment & OTF process | 5d | 2012-03-05 A | 2012-03-09 A |  | 100% |  |  | Janet | 40h | 40h |
| 47 | 1.2.3.7 | **Housing Stakeholder - Student Financial Services** | 5d | 2012-03-13 A | 2012-03-19 A | 40FS+1d | 100% |  |  |  | 48h | 48h |
| 48 | 1.2.3.7.1 | Assess primary users/roles | 5d | 2012-03-13 A | 2012-03-19 A |  | 100% |  |  | Ross [40%] | 16h | 16h |
| 49 | 1.2.3.7.2 | Discuss systems/process flow | 5d | 2012-03-13 A | 2012-03-19 A |  | 100% |  |  | Ross [40%] | 16h | 16h |
| 50 | 1.2.3.7.3 | Discuss process calendar | 5d | 2012-03-13 A | 2012-03-19 A |  | 100% |  |  | Ross [40%] | 16h | 16h |
| 51 | 1.2.3.8 | **Housing Stakeholder - Registrar** | 5d | 2012-03-21 A | 2012-03-27 A | 47FS+1d | 100% |  |  |  | 120h | 120h |
| 52 | 1.2.3.8.1 | Evaluate scope of affected data/process/systems | 5d | 2012-03-21 A | 2012-03-27 A |  | 100% |  |  | Janet | 40h | 40h |
| 53 | 1.2.3.8.2 | Examine dataflow for MITSIS Directory information | 5d | 2012-03-21 A | 2012-03-27 A |  | 100% |  |  | Janet | 40h | 40h |
| 54 | 1.2.3.8.3 | Examine current supporting processes & functionality | 5d | 2012-03-21 A | 2012-03-27 A |  | 100% |  |  | Janet | 40h | 40h |
| 55 | 1.2.3.9 | Housing Stakeholders - Card Office / SEMO I | 1d | 2012-03-23 A | 2012-03-23 A |  | 100% |  | start no earlier than 2012-03-23 | Ross [40%] | 3.2h | 3.2h |
| 56 | 1.2.3.10 | Housing Stakeholders - Campus Dining | 1d | 2012-04-04 | 2012-04-04 |  |  | 35d | start no earlier than 2012-04-04 | Ross [40%] | 3.2h |  |
| 57 | 1.2.3.11 | Housing Stakeholders - Tech Cash | 1d | 2012-04-04 | 2012-04-04 |  |  | 35d | start no earlier than 2012-04-04 |  |  |  |
| 58 | 1.2.3.12 | UG House Managers | 1d | 2012-04-12 | 2012-04-12 |  |  | 29d | start no earlier than 2012-04-12 | Janet [40%] | 3.2h |  |
| 59 | 1.2.3.13 | GRAD House Managers | 1d | 2012-04-17 | 2012-04-17 |  |  | 26d | start no earlier than 2012-04-17 |  |  |  |
| 60 | 1.2.3.14 | FSILG | 1d | 2012-04-18 | 2012-04-18 |  |  | 25d | start no earlier than 2012-04-18 | Janet [40%] | 3.2h |  |
| 61 | 1.2.3.15 | Housing Stakeholders - Card Office / SEMO II | 1d | 2012-04-23 | 2012-04-23 |  |  | 22d | start no earlier than 2012-04-23 | Janet | 8h |  |
| 62 | 1.2.3.16 | Dean On Call | 1d | 2012-05-09 | 2012-05-09 |  |  | 0d | start no earlier than 2012-05-09 |  |  |  |

| ID | WBS | Task | Type | Duration | Start | Finish | Predecessors | Total slack | Constraint | Resources | Work |
| --- | --- | --- | --- | --- | --- | --- | --- | --- | --- | --- | --- |
| 63 | 1.2.3.17 | **CBORD** |  | 10d | 2012-05-10 | 2012-05-23 | 62 | 0d |  |  | 96h |
| 64 | 1.2.3.17.1 | Digital Building / Room Setup & Maintenance |  | 10d | 2012-05-10 | 2012-05-23 |  | 0d | start no earlier than 2012-01-23 | Ross [40%] | 32h |
| 65 | 1.2.3.17.2 | Room Rate Code Setup & Maintenance |  | 10d | 2012-05-10 | 2012-05-23 |  | 0d | start no earlier than 2012-03-05 | Ross [40%] | 32h |
| 66 | 1.2.3.17.3 | Current Security, Roles & Authorization, and structures for housing applications |  | 10d | 2012-05-10 | 2012-05-23 |  | 0d | start no earlier than 2012-03-05 | Ross [40%] | 32h |
| 67 | 1.2.4 | **Discovery Phase Documentation** |  | 50d | 2012-05-03 | 2012-07-11 | 16FS-15d | 0d |  |  | 512h |
| 68 | 1.2.4.1 | **As-Is Process Maps** |  | 30d | 2012-05-03 | 2012-06-13 |  | 0d |  |  | 192h |
| 69 | 1.2.4.1.1 | Graduate Students |  | 10d | 2012-05-03 | 2012-05-16 |  | 0d | start no earlier than 2012-02-17 | Janet [40%] | 32h |
| 70 | 1.2.4.1.2 | Undergraduate Students |  | 10d | 2012-05-03 | 2012-05-16 |  | 0d | start no earlier than 2012-02-17 | Ross [40%] | 32h |
| 71 | 1.2.4.1.3 | Vacancy |  | 10d | 2012-05-17 | 2012-05-30 | 69 | 0d | start no earlier than 2012-02-27 | Janet [40%] | 32h |
| 72 | 1.2.4.1.4 | Transfers |  | 10d | 2012-05-31 | 2012-06-13 | 71 | 0d | start no earlier than 2012-02-27 | Janet [40%] | 32h |
| 73 | 1.2.4.1.5 | Early Returns |  | 10d | 2012-05-17 | 2012-05-30 | 70 | 0d | start no earlier than 2012-02-27 | Ross [40%] | 32h |
| 74 | 1.2.4.1.6 | Wait List |  | 10d | 2012-05-31 | 2012-06-13 | 73 | 0d | start no earlier than 2012-02-27 | Ross [40%] | 32h |
| 75 | 1.2.4.1.7 | As-Is Process Maps completed | milestone | 0d | 2012-06-13 | 2012-06-13 | 69, 70, 71, 72, 73, 74 | 0d |  |  |  |
| 76 | 1.2.4.2 | **Data Catagories that are tracked between systems** |  | 20d | 2012-06-14 | 2012-07-11 | 68 | 0d |  |  | 192h |
| 77 | 1.2.4.2.1 | Housing |  | 20d | 2012-06-14 | 2012-07-11 |  | 0d | start no earlier than 2012-03-26 | Ross [40%] | 64h |
| 78 | 1.2.4.2.2 | Biographical |  | 20d | 2012-06-14 | 2012-07-11 |  | 0d | start no earlier than 2012-03-26 | Janet [40%] | 64h |
| 79 | 1.2.4.2.3 | Preferences |  | 20d | 2012-06-14 | 2012-07-11 |  | 0d | start no earlier than 2012-03-26 | Ross [40%] | 64h |
| 80 | 1.2.4.3 | Dual Entry areas / Pain Points |  | 20d | 2012-06-14 | 2012-07-11 | 68 | 0d | start no earlier than 2012-03-26 | Janet [40%] | 64h |
| 81 | 1.2.4.4 | Project Wiki |  | 20d | 2012-06-14 | 2012-07-11 | 68 | 0d | start no earlier than 2012-03-26 | Ross [40%] | 64h |
| 82 | 1.2.5 | Review with Project Team, Stakeholders |  | 5d | 2012-07-12 | 2012-07-18 | 67 | 0d |  |  |  |
| 83 | 1.2.6 | Discovery Phase Completed | milestone | 0d | 2012-07-18 | 2012-07-18 | 82 | 0d |  |  |  |
| 84 | 1.3 | Define Phase |  | 50d | 2012-07-19 | 2012-09-26 | 83 | 0d |  |  |  |
| 85 | 1.4 | Design Phase |  | 50d | 2012-09-27 | 2012-12-05 | 84 | 0d |  |  |  |

Notes:
- 68: Need to show calendar and stakeholders
- 76: Data Catagories for CBord and for MITSIS
